# پروژه احداث تأسيسات پشتيباني

Schedule from MS Project, 2006-09-02 to 2008-05-12, status date 2006-09-02.
Tadbir & Tarh Puya

## Calendars

- Standard: Mon-Sun 08:00-16:00.

## Schedule

| ID | WBS | Task | Type | Duration | Start | Finish | Predecessors | Baseline start | Baseline finish | Baseline duration | Total slack | Free slack | Constraint |
| --- | --- | --- | --- | --- | --- | --- | --- | --- | --- | --- | --- | --- | --- |
| 1 | 0 | ابلاغ قرارداد | milestone | 0d | 2006-09-02 | 2006-09-02 |  | 2006-09-02 | 2006-09-02 | 0d | 0d |  |  |
| 2 | 1 | **تحويل زمين** |  | 16d | 2006-09-05 | 2006-09-20 |  |  |  |  | 0d |  |  |
| 3 | 1.1 | کنترل و تحويل نقاط نقشه برداري |  | 6d | 2006-09-05 | 2006-09-10 | 1FS+3d | 2006-09-05 | 2006-09-10 | 6d | 0d |  | start no earlier than 2006-09-02 |
| 4 | 1.2 | تنظيم صورتجلسه تحويل زمين | milestone | 0d | 2006-09-20 | 2006-09-20 | 3FS+10d | 2006-09-20 | 2006-09-20 | 0d | 0d |  |  |
| 5 | 2 | **نقشه‌برداري اوليه** |  | 15d | 2006-09-21 | 2006-10-05 |  |  |  |  | 77d |  |  |
| 6 | 2.1 | برداشت مشترک محوطه و خيابانها |  | 5d | 2006-09-21 | 2006-09-25 | 4 | 2006-09-21 | 2006-09-25 | 5d | 77d | 0d |  |
| 7 | 2.2 | اخذ تائيديه مشاور و كارفرما | milestone | 0d | 2006-10-05 | 2006-10-05 | 6FS+10d | 2006-10-05 | 2006-10-05 | 0d | 77d |  |  |
| 8 | 3 | **شناسائي معدن** |  | 25d | 2006-09-21 | 2006-10-15 |  |  |  |  | 87d |  |  |
| 9 | 3.1 | شناسائي معدن |  | 20d | 2006-09-21 | 2006-10-10 | 4 | 2006-09-21 | 2006-10-10 | 20d | 87d | 0d |  |
| 10 | 3.2 | صدور مجوز برداشت | milestone | 0d | 2006-10-15 | 2006-10-15 | 9FS+5d | 2006-10-15 | 2006-10-15 | 0d | 87d |  |  |
| 11 | 4 | **تجهيز کارگاه** |  | 578d | 2006-09-22 | 2008-04-23 |  |  |  |  | 0d |  |  |
| 12 | 4.1 | تعيين محل تجهيز کارکاه | milestone | 0d | 2006-09-22 | 2006-09-22 | 4FS+2d | 2006-09-23 | 2006-09-23 | 0d | 0d |  |  |
| 13 | 4.2 | تهيه پلان محل استقرار |  | 5d | 2006-09-25 | 2006-09-29 | 12FS+2d | 2006-09-25 | 2006-09-29 | 5d | 0d |  |  |
| 14 | 4.3 | اخذ تائيديه مشاور | milestone | 0d | 2006-10-04 | 2006-10-04 | 13FS+5d | 2006-10-04 | 2006-10-04 | 0d | 0d |  |  |
| 15 | 4.4 | احداث ساختمانهاي اداري - مسکوني |  | 30d | 2006-10-08 | 2006-11-06 | 14FS+3d | 2006-10-08 | 2006-11-06 | 30d | 0d |  |  |
| 16 | 4.5 | تأمين برق، مخابرات و آب |  | 15d | 2006-11-02 | 2006-11-16 | 15FS-5d | 2006-11-02 | 2006-11-16 | 15d | 543d |  |  |
| 17 | 4.6 | استقرار ماشين آلات |  | 15d | 2006-11-02 | 2006-11-16 | 15FS-5d | 2006-11-02 | 2006-11-16 | 15d | 543d |  |  |
| 18 | 4.7 | محوطه‌سازي و خدمات تکميلي کارگاه |  | 45d | 2006-11-07 | 2006-12-21 | 15 | 2006-11-07 | 2006-11-21 | 15d | 0d |  |  |
| 19 | 4.7 | تجهيز کارگاه تكميلي |  | 488d | 2006-12-22 | 2008-04-23 | 18, 215SF | 2006-11-07 | 2006-11-21 | 15d | 20d |  |  |
| 20 | 5 | **احداث ساختمانها** |  | 384d | 2006-12-22 | 2008-01-09 |  |  |  |  | 124d |  |  |
| 21 | 5.1 | **ساختمان اداري** |  | 195d | 2006-12-22 | 2007-07-04 |  |  |  |  | 124d |  |  |
| 22 | 5.1.1 | پي كني و اجراي بتن مگر |  | 7d | 2006-12-22 | 2006-12-28 | 18 | 2006-11-22 | 2006-11-28 | 7d | 124d | 0d |  |
| 23 | 5.1.2 | قالب‌بندي، آرماتوربندي و اجراي فونداسيون |  | 20d | 2006-12-29 | 2007-01-17 | 22 | 2006-11-29 | 2006-12-18 | 20d | 124d | 0d |  |
| 24 | 5.1.3 | نصب صفحه ستونها و ستون گذاري |  | 8d | 2007-01-23 | 2007-01-30 | 23FS+5d | 2006-12-24 | 2006-12-31 | 8d | 313d | 0d |  |
| 25 | 5.1.4 | تيرريزي و اجراي بادبندهاي كل ساختمان |  | 16d | 2007-01-31 | 2007-02-15 | 24 | 2007-01-01 | 2007-01-16 | 16d | 313d | 0d |  |
| 26 | 5.1.5 | رنگ آميزي اپوکسي سطوح فلزي مورد نياز |  | 6d | 2007-02-16 | 2007-02-21 | 25 | 2007-01-17 | 2007-01-22 | 6d | 313d | 0d |  |
| 27 | 5.1.6 | اجراي سقف تيرچه و بلوک تراز اول |  | 10d | 2007-02-22 | 2007-03-03 | 26 | 2007-01-23 | 2007-02-01 | 10d | 313d | 0d |  |
| 28 | 5.1.7 | اجراي سقف تيرچه و بلوک تراز دوم |  | 10d | 2007-03-11 | 2007-03-20 | 27FS+7d | 2007-02-09 | 2007-02-18 | 10d | 313d | 0d |  |
| 29 | 5.1.8 | اجراي پوشش بام با پوكه و موزائيك |  | 8d | 2007-03-21 | 2007-03-28 | 28 | 2007-02-19 | 2007-02-26 | 8d | 411d |  |  |
| 30 | 5.1.9 | اجراي ديوارها |  | 20d | 2007-03-11 | 2007-03-30 | 28SS | 2007-02-09 | 2007-02-28 | 20d | 313d | 0d |  |
| 31 | 5.1.10 | ساخت و نصب درب و پنجره‌هاي فلزي |  | 20d | 2007-03-11 | 2007-03-30 | 30FF | 2007-02-09 | 2007-02-28 | 20d | 409d |  |  |
| 32 | 5.1.11 | اجراي تأسيسات برقي ساختمان |  | 30d | 2007-03-31 | 2007-04-29 | 30 | 2007-03-01 | 2007-03-30 | 30d | 323d | 10d |  |
| 33 | 5.1.12 | اجراي تأسيسات مكانيكي ساختمان |  | 40d | 2007-03-31 | 2007-05-09 | 30 | 2007-03-01 | 2007-04-09 | 40d | 313d | 0d |  |
| 34 | 5.1.13 | عايق‌كاري، نازك كاري و سفيد كاري |  | 20d | 2007-05-10 | 2007-05-29 | 32, 33 | 2007-04-10 | 2007-04-29 | 20d | 313d | 0d |  |
| 35 | 5.1.14 | كف‌سازي و اجراي سقف كاذب |  | 20d | 2007-05-30 | 2007-06-18 | 34 | 2007-04-30 | 2007-05-19 | 20d | 313d | 0d |  |
| 36 | 5.1.15 | نصب درهاي داخل ساختمان و رنگ آميزي سطوح ديوارها و دربها |  | 20d | 2007-06-15 | 2007-07-04 | 35FS-4d | 2007-05-16 | 2007-06-04 | 20d | 313d | 0d |  |
| 37 | 5.1.16 | اجراي كارهاي سنگي |  | 12d | 2007-05-18 | 2007-05-29 | 34FF | 2007-04-18 | 2007-04-29 | 12d | 322d | 0d |  |
| 38 | 5.1.17 | اجراي آجر نما |  | 25d | 2007-05-30 | 2007-06-23 | 30, 37 | 2007-04-30 | 2007-05-24 | 25d | 322d | 9d |  |
| 39 | 5.1.18 | نصب شيشه |  | 2d | 2007-07-03 | 2007-07-04 | 38, 36FF | 2007-06-03 | 2007-06-04 | 2d | 313d |  |  |

| ID | WBS | Task | Duration | Start | Finish | Predecessors | Baseline start | Baseline finish | Baseline duration | Total slack | Free slack |
| --- | --- | --- | --- | --- | --- | --- | --- | --- | --- | --- | --- |
| 40 | 5.2 | **ساختمان آمارگيران و سايبان مركزي** | 195d | 2006-12-22 | 2007-07-04 |  |  |  |  | 151d |  |
| 41 | 5.2.1 | طراحي جزئيات و ساخت المانهاي سازه فضاكار | 58d | 2006-12-22 | 2007-02-17 | 18 | 2006-11-22 | 2007-01-18 | 58d | 415d | 0d |
| 42 | 5.2.2 | پي كني و اجراي بتن مگر سايبان | 7d | 2007-01-18 | 2007-01-24 | 23 | 2006-12-19 | 2006-12-25 | 7d | 124d | 0d |
| 43 | 5.2.3 | قالب‌بندي، آرماتوربندي و اجراي فونداسيون سايبان | 15d | 2007-01-25 | 2007-02-08 | 42 | 2006-12-26 | 2007-01-09 | 15d | 124d | 0d |
| 44 | 5.2.4 | نصب صفحه ستونها و ستون گذاري سايبان | 4d | 2007-02-14 | 2007-02-17 | 43FS+5d | 2007-01-15 | 2007-01-18 | 4d | 415d | 0d |
| 45 | 5.2.5 | نصب سازه فضاكار | 15d | 2007-02-18 | 2007-03-04 | 44, 41 | 2007-01-19 | 2007-02-02 | 15d | 415d | 0d |
| 46 | 5.2.6 | رنگ آميزي اپوکسي سطوح فلزي مورد نياز سايبان | 10d | 2007-03-05 | 2007-03-14 | 45 | 2007-02-03 | 2007-02-12 | 10d | 415d | 0d |
| 47 | 5.2.7 | اجراي پانل ساندويچي سقفي | 10d | 2007-03-15 | 2007-03-24 | 46 | 2007-02-13 | 2007-02-22 | 10d | 415d |  |
| 48 | 5.2.8 | پي كني و اجراي بتن مگر ساختمان آمارگيران | 7d | 2007-02-06 | 2007-02-12 | 43FS-3d | 2006-12-19 | 2006-12-25 | 7d | 124d | 0d |
| 49 | 5.2.9 | قالب‌بندي، آرماتوربندي و اجراي فونداسيون ساختمان آمارگيران | 15d | 2007-02-13 | 2007-02-27 | 48 | 2006-12-26 | 2007-01-09 | 15d | 124d | 0d |
| 50 | 5.2.10 | نصب صفحه ستونها و ستون گذاري ساختمان آمارگيران | 6d | 2007-03-05 | 2007-03-10 | 49FS+5d | 2007-02-03 | 2007-02-08 | 6d | 313d | 0d |
| 51 | 5.2.11 | تيرريزي و اجراي بادبندهاي ساختمان آمارگيران | 10d | 2007-03-11 | 2007-03-20 | 50 | 2007-02-09 | 2007-02-18 | 10d | 313d | 0d |
| 52 | 5.2.12 | رنگ آميزي اپوکسي سطوح فلزي مورد نياز | 8d | 2007-03-21 | 2007-03-28 | 51 | 2007-02-19 | 2007-02-26 | 8d | 313d | 0d |
| 53 | 5.2.13 | اجراي دال بتوني سقف تراز اول | 10d | 2007-03-29 | 2007-04-07 | 52 | 2007-02-27 | 2007-03-08 | 10d | 313d | 0d |
| 54 | 5.2.14 | اجراي پانل ساندويچي سقف تراز دوم | 10d | 2007-04-15 | 2007-04-24 | 53FS+7d | 2007-03-16 | 2007-03-25 | 10d | 313d | 0d |
| 55 | 5.2.15 | اجراي ديوارها | 20d | 2007-04-15 | 2007-05-04 | 54SS | 2007-03-16 | 2007-04-04 | 20d | 313d | 0d |
| 56 | 5.2.16 | ساخت و نصب درب و پنجره‌هاي فلزي | 15d | 2007-04-20 | 2007-05-04 | 55FF | 2007-03-21 | 2007-04-04 | 15d | 374d |  |
| 57 | 5.2.17 | اجراي تأسيسات برقي ساختمان | 20d | 2007-05-05 | 2007-05-24 | 55 | 2007-04-05 | 2007-04-24 | 20d | 313d | 0d |
| 58 | 5.2.18 | اجراي تأسيسات مكانيكي ساختمان | 16d | 2007-05-09 | 2007-05-24 | 57FF | 2007-04-09 | 2007-04-24 | 16d | 313d | 0d |
| 59 | 5.2.19 | نازك كاري و سفيد كاري | 15d | 2007-05-25 | 2007-06-08 | 57, 58 | 2007-04-25 | 2007-05-09 | 15d | 313d | 0d |
| 60 | 5.2.20 | كف‌سازي | 10d | 2007-06-09 | 2007-06-18 | 59 | 2007-05-10 | 2007-05-19 | 10d | 313d | 0d |
| 61 | 5.2.21 | اجراي كارهاي سنگي | 10d | 2007-06-09 | 2007-06-18 | 60FF | 2007-05-10 | 2007-05-19 | 10d | 313d | 0d |
| 62 | 5.2.22 | اجراي آجر نما | 15d | 2007-06-19 | 2007-07-03 | 55, 61 | 2007-05-20 | 2007-06-03 | 15d | 313d | 0d |
| 63 | 5.2.23 | نصب درهاي داخل ساختمان و رنگ آميزي سطوح ديوارها و دربها | 15d | 2007-06-15 | 2007-06-29 | 60FS-4d | 2007-05-16 | 2007-05-30 | 15d | 318d | 5d |
| 64 | 5.2.24 | نصب شيشه | 1d | 2007-07-04 | 2007-07-04 | 62, 63FF | 2007-06-04 | 2007-06-04 | 1d | 313d |  |

| ID | WBS | Task | Duration | Start | Finish | Predecessors | Baseline start | Baseline finish | Baseline duration | Total slack | Free slack |
| --- | --- | --- | --- | --- | --- | --- | --- | --- | --- | --- | --- |
| 65 | 5.3 | **سايبان‌هاي اسکله** | 88d | 2007-01-12 | 2007-04-09 |  |  |  |  | 399d |  |
| 66 | 5.3.1 | ساخت سازه‌هاي فلزي سايبانها | 50d | 2007-01-12 | 2007-03-02 | 18FS+21d | 2006-12-13 | 2007-01-31 | 50d | 399d | 0d |
| 67 | 5.3.2 | نصب سايبانها | 10d | 2007-03-03 | 2007-03-12 | 66 | 2007-02-01 | 2007-02-10 | 10d | 399d | 0d |
| 68 | 5.3.3 | رنگ آميزي اپوکسي سطوح فلزي مورد نياز | 8d | 2007-03-13 | 2007-03-20 | 67 | 2007-02-11 | 2007-02-18 | 8d | 399d | 0d |
| 69 | 5.3.4 | اجراي پانل ساندويچي سقفي | 10d | 2007-03-21 | 2007-03-30 | 68 | 2007-02-19 | 2007-02-28 | 10d | 399d | 0d |
| 70 | 5.3.5 | اجراي تأسيسات برقي | 10d | 2007-03-31 | 2007-04-09 | 69 | 2007-03-01 | 2007-03-10 | 10d | 399d |  |
| 71 | 5.4 | **ساختمان نمازخانه** | 158d | 2007-03-10 | 2007-08-14 |  |  |  |  | 124d |  |
| 72 | 5.4.1 | پي كني و اجراي بتن مگر | 5d | 2007-03-10 | 2007-03-14 | 49FS+10d | 2007-01-20 | 2007-01-24 | 5d | 124d | 0d |
| 73 | 5.4.2 | قالب‌بندي، آرماتوربندي و اجراي فونداسيون | 15d | 2007-03-15 | 2007-03-29 | 72 | 2007-01-25 | 2007-02-08 | 15d | 124d | 0d |
| 74 | 5.4.3 | نصب صفحه ستونها و ستون گذاري | 10d | 2007-04-04 | 2007-04-13 | 73FS+5d | 2007-02-14 | 2007-02-23 | 10d | 272d | 0d |
| 75 | 5.4.4 | تيرريزي و اجراي بادبندهاي كل ساختمان | 10d | 2007-04-14 | 2007-04-23 | 74 | 2007-02-24 | 2007-03-05 | 10d | 272d | 0d |
| 76 | 5.4.5 | رنگ آميزي اپوکسي سطوح فلزي مورد نياز | 8d | 2007-04-24 | 2007-05-01 | 75 | 2007-03-06 | 2007-03-13 | 8d | 272d | 0d |
| 77 | 5.4.6 | اجراي ديوارها | 30d | 2007-05-02 | 2007-05-31 | 76 | 2007-03-14 | 2007-04-12 | 30d | 272d | 0d |
| 78 | 5.4.7 | اجراي سقف و نصب پانل ساندويچي سقفي | 35d | 2007-06-01 | 2007-07-05 | 77 | 2007-04-13 | 2007-05-17 | 35d | 272d | 0d |
| 79 | 5.4.8 | اجراي تأسيسات برقي ساختمان | 15d | 2007-07-06 | 2007-07-20 | 78 | 2007-05-18 | 2007-06-01 | 15d | 272d | 0d |
| 80 | 5.4.9 | اجراي تأسيسات مكانيكي ساختمان | 10d | 2007-07-11 | 2007-07-20 | 79FF | 2007-05-23 | 2007-06-01 | 10d | 272d | 0d |
| 81 | 5.4.10 | عايق‌كاري، كف‌سازي | 10d | 2007-07-21 | 2007-07-30 | 79, 80 | 2007-06-02 | 2007-06-11 | 10d | 272d | 0d |
| 82 | 5.4.11 | اجراي كارهاي سنگي | 8d | 2007-07-23 | 2007-07-30 | 81FF | 2007-06-04 | 2007-06-11 | 8d | 272d | 0d |
| 83 | 5.4.12 | اجراي آجر نما | 15d | 2007-07-31 | 2007-08-14 | 77, 82 | 2007-06-12 | 2007-06-26 | 15d | 272d |  |
| 84 | 5.5 | **سرويس‌هاي بهداشتي** | 111d | 2007-04-09 | 2007-07-28 |  |  |  |  | 124d |  |
| 85 | 5.5.1 | پي كني و اجراي بتن مگر | 5d | 2007-04-09 | 2007-04-13 | 73FS+10d | 2007-02-19 | 2007-02-23 | 5d | 124d | 0d |
| 86 | 5.5.2 | قالب‌بندي، آرماتوربندي و اجراي فونداسيون | 15d | 2007-04-14 | 2007-04-28 | 85 | 2007-02-24 | 2007-03-10 | 15d | 124d | 0d |
| 87 | 5.5.3 | نصب صفحه ستونها و ستون گذاري | 6d | 2007-05-04 | 2007-05-09 | 86FS+5d | 2007-03-16 | 2007-03-21 | 6d | 289d | 0d |
| 88 | 5.5.4 | تيرريزي و اجراي بادبندهاي كل ساختمان | 8d | 2007-05-10 | 2007-05-17 | 87 | 2007-03-22 | 2007-03-29 | 8d | 289d | 0d |
| 89 | 5.5.5 | رنگ آميزي اپوکسي سطوح فلزي مورد نياز | 3d | 2007-05-18 | 2007-05-20 | 88 | 2007-03-30 | 2007-04-01 | 3d | 289d | 0d |
| 90 | 5.5.6 | اجراي سقف تيرچه و بلوک | 5d | 2007-05-21 | 2007-05-25 | 89 | 2007-04-02 | 2007-04-06 | 5d | 289d | 0d |
| 91 | 5.5.7 | اجراي پوشش بام با پوكه و موزائيك | 5d | 2007-05-26 | 2007-05-30 | 90 | 2007-04-07 | 2007-04-11 | 5d | 348d |  |
| 92 | 5.5.8 | اجراي ديوارها | 8d | 2007-06-05 | 2007-06-12 | 90FS+10d | 2007-04-17 | 2007-04-24 | 8d | 289d | 0d |
| 93 | 5.5.9 | ساخت و نصب درب و پنجره‌هاي فلزي | 10d | 2007-06-03 | 2007-06-12 | 92FF | 2007-04-15 | 2007-04-24 | 10d | 335d |  |
| 94 | 5.5.10 | اجراي تأسيسات برقي ساختمان | 15d | 2007-06-13 | 2007-06-27 | 92 | 2007-04-25 | 2007-05-09 | 15d | 289d | 0d |
| 95 | 5.5.11 | اجراي تأسيسات مكانيكي ساختمان | 15d | 2007-06-13 | 2007-06-27 | 92 | 2007-04-25 | 2007-05-09 | 15d | 289d | 0d |
| 96 | 5.5.12 | عايق‌كاري، نازك كاري و سفيد كاري | 15d | 2007-06-28 | 2007-07-12 | 94, 95 | 2007-05-10 | 2007-05-24 | 15d | 289d | 0d |
| 97 | 5.5.13 | كف‌سازي | 10d | 2007-07-13 | 2007-07-22 | 96 | 2007-05-25 | 2007-06-03 | 10d | 289d | 0d |
| 98 | 5.5.14 | نصب درهاي داخل ساختمان و رنگ آميزي سطوح ديوارها و دربها | 10d | 2007-07-19 | 2007-07-28 | 97FS-4d | 2007-05-31 | 2007-06-09 | 10d | 289d | 0d |
| 99 | 5.5.15 | اجراي كارهاي سنگي | 6d | 2007-07-12 | 2007-07-17 | 96FF+5d | 2007-05-24 | 2007-05-29 | 6d | 289d | 0d |
| 100 | 5.5.16 | اجراي آجر نما | 10d | 2007-07-18 | 2007-07-27 | 92, 99 | 2007-05-30 | 2007-06-08 | 10d | 289d | 0d |
| 101 | 5.5.17 | نصب شيشه | 1d | 2007-07-28 | 2007-07-28 | 100, 98FF | 2007-06-09 | 2007-06-09 | 1d | 289d |  |

| ID | WBS | Task | Duration | Start | Finish | Predecessors | Baseline start | Baseline finish | Baseline duration | Total slack | Free slack |
| --- | --- | --- | --- | --- | --- | --- | --- | --- | --- | --- | --- |
| 102 | 5.6 | **ساختمان پمپ‌خانه و مخازن بتني آب** | 164d | 2007-05-09 | 2007-10-19 |  |  |  |  | 124d |  |
| 103 | 5.6.1 | پي‌كني و بتن مگر | 6d | 2007-05-09 | 2007-05-14 | 86FS+10d | 2007-03-21 | 2007-03-26 | 6d | 124d | 0d |
| 104 | 5.6.2 | قالب‌بندي، آرماتوربندي و اجراي فونداسيون | 15d | 2007-05-15 | 2007-05-29 | 103 | 2007-03-27 | 2007-04-10 | 15d | 206d | 0d |
| 105 | 5.6.3 | اجراي ديوارها | 25d | 2007-06-06 | 2007-06-30 | 104FS+7d | 2007-04-18 | 2007-05-12 | 25d | 206d | 0d |
| 106 | 5.6.4 | اجراي دال بتني سقف | 20d | 2007-07-06 | 2007-07-25 | 105FS+5d | 2007-05-18 | 2007-06-06 | 20d | 206d | 0d |
| 107 | 5.6.5 | اجراي پوشش بام با پوكه و موزائيك | 6d | 2007-07-26 | 2007-07-31 | 106 | 2007-06-07 | 2007-06-12 | 6d | 286d |  |
| 108 | 5.6.6 | ساخت و نصب درب و پنجره‌ها | 10d | 2007-07-26 | 2007-08-04 | 106 | 2007-06-07 | 2007-06-16 | 10d | 206d | 0d |
| 109 | 5.6.7 | اجراي تأسيسات مكانيكي ساختمان | 30d | 2007-08-05 | 2007-09-03 | 108 | 2007-06-17 | 2007-07-16 | 30d | 206d | 0d |
| 110 | 5.6.8 | اجراي تأسيسات برقي ساختمان | 20d | 2007-08-15 | 2007-09-03 | 109FF | 2007-06-27 | 2007-07-16 | 20d | 206d | 0d |
| 111 | 5.6.9 | عايق‌كاري، نازك‌كاري، نماسازي و كف‌سازي | 25d | 2007-09-04 | 2007-09-28 | 109, 110 | 2007-07-17 | 2007-08-10 | 25d | 206d | 0d |
| 112 | 5.6.10 | نصب شيشه | 1d | 2007-09-29 | 2007-09-29 | 111 | 2007-08-11 | 2007-08-11 | 1d | 206d | 0d |
| 113 | 5.6.11 | ساخت و نصب مخازن آب شيرين | 20d | 2007-09-30 | 2007-10-19 | 112 | 2007-08-12 | 2007-08-31 | 20d | 206d |  |
| 114 | 5.7 | **سپتيک تانک و پمپ‌خانه فاضلاب** | 100d | 2007-05-19 | 2007-08-26 |  |  |  |  | 124d |  |
| 115 | 5.7.1 | پي‌كني و بتن مگر | 8d | 2007-05-19 | 2007-05-26 | 103SS+10d | 2007-03-31 | 2007-04-07 | 8d | 124d | 0d |
| 116 | 5.7.2 | قالب‌بندي، آرماتوربندي و اجراي فونداسيون | 20d | 2007-05-27 | 2007-06-15 | 115 | 2007-04-08 | 2007-04-27 | 20d | 124d | 0d |
| 117 | 5.7.3 | اجراي ديوارها | 25d | 2007-06-23 | 2007-07-17 | 116FS+7d | 2007-05-05 | 2007-05-29 | 25d | 124d | 0d |
| 118 | 5.7.4 | اجراي سقف تيرچه و بلوك | 10d | 2007-07-23 | 2007-08-01 | 117FS+5d | 2007-06-04 | 2007-06-13 | 10d | 124d | 0d |
| 119 | 5.7.5 | اجراي تأسيسات مكانيكي ساختمان | 25d | 2007-08-02 | 2007-08-26 | 118 | 2007-06-14 | 2007-07-08 | 25d | 124d | 0d |
| 120 | 5.7.6 | اجراي تأسيسات برقي ساختمان | 15d | 2007-08-12 | 2007-08-26 | 119FF | 2007-06-24 | 2007-07-08 | 15d | 124d | 0d |
| 121 | 5.8 | **سايبان مخزن سوخت** | 73d | 2007-06-16 | 2007-08-27 |  |  |  |  | 259d |  |
| 122 | 5.8.1 | پي‌كني و بتن مگر | 6d | 2007-06-16 | 2007-06-21 | 116 | 2007-04-28 | 2007-05-03 | 6d | 259d | 0d |
| 123 | 5.8.2 | قالب‌بندي، آرماتوربندي و اجراي فونداسيون | 15d | 2007-06-22 | 2007-07-06 | 122 | 2007-05-04 | 2007-05-18 | 15d | 259d | 0d |
| 124 | 5.8.3 | نصب صفحه ستونها و ستون گذاري | 4d | 2007-07-14 | 2007-07-17 | 123FS+7d | 2007-05-26 | 2007-05-29 | 4d | 259d | 0d |
| 125 | 5.8.4 | تيرريزي و اجراي بادبندهاي كل ساختمان | 6d | 2007-07-18 | 2007-07-23 | 124 | 2007-05-30 | 2007-06-04 | 6d | 259d | 0d |
| 126 | 5.8.5 | رنگ آميزي اپوکسي سطوح فلزي مورد نياز | 5d | 2007-07-24 | 2007-07-28 | 125 | 2007-06-05 | 2007-06-09 | 5d | 259d | 0d |
| 127 | 5.8.6 | نصب پانل ساندويچي سقفي | 5d | 2007-08-03 | 2007-08-07 | 126FS+5d | 2007-06-15 | 2007-06-19 | 5d | 259d | 0d |
| 128 | 5.8.7 | اجراي تأسيسات مكانيكي ساختمان | 15d | 2007-08-08 | 2007-08-22 | 127 | 2007-06-20 | 2007-07-04 | 15d | 259d | 0d |
| 129 | 5.8.8 | اجراي تأسيسات برقي ساختمان | 10d | 2007-08-13 | 2007-08-22 | 128FF | 2007-06-25 | 2007-07-04 | 10d | 264d |  |
| 130 | 5.8.9 | ساخت و نصب منبع سوخت | 5d | 2007-08-23 | 2007-08-27 | 128 | 2007-07-05 | 2007-07-09 | 5d | 259d |  |

| ID | WBS | Task | Duration | Start | Finish | Predecessors | Baseline start | Baseline finish | Baseline duration | Total slack | Free slack |
| --- | --- | --- | --- | --- | --- | --- | --- | --- | --- | --- | --- |
| 131 | 5.9 | **ساختمان نگهباني** | 136d | 2007-08-27 | 2008-01-09 |  |  |  |  | 124d |  |
| 132 | 5.9.1 | پي كني و اجراي بتن مگر | 5d | 2007-08-27 | 2007-08-31 | 120 | 2007-07-09 | 2007-07-13 | 5d | 124d | 0d |
| 133 | 5.9.2 | قالب‌بندي، آرماتوربندي و اجراي فونداسيون | 15d | 2007-09-01 | 2007-09-15 | 132 | 2007-07-14 | 2007-07-28 | 15d | 124d | 0d |
| 134 | 5.9.3 | اجراي شناژهاي قائم و ديوارها | 20d | 2007-09-21 | 2007-10-10 | 133FS+5d | 2007-08-03 | 2007-08-22 | 20d | 124d | 0d |
| 135 | 5.9.4 | اجراي دال بتوني سقف | 15d | 2007-10-11 | 2007-10-25 | 134 | 2007-08-23 | 2007-09-06 | 15d | 124d | 0d |
| 136 | 5.9.5 | اجراي پوشش بام با پوكه و موزائيك | 8d | 2007-10-26 | 2007-11-02 | 135 | 2007-09-07 | 2007-09-14 | 8d | 192d |  |
| 137 | 5.9.6 | ساخت و نصب درب و پنجره‌هاي فلزي | 20d | 2007-10-26 | 2007-11-14 | 135 | 2007-09-07 | 2007-09-26 | 20d | 124d | 0d |
| 138 | 5.9.7 | اجراي تأسيسات برقي ساختمان | 15d | 2007-11-15 | 2007-11-29 | 137 | 2007-09-27 | 2007-10-11 | 15d | 124d | 0d |
| 139 | 5.9.8 | اجراي تأسيسات مكانيكي ساختمان | 10d | 2007-11-20 | 2007-11-29 | 138FF | 2007-10-02 | 2007-10-11 | 10d | 124d | 0d |
| 140 | 5.9.9 | عايق‌كاري، نازك كاري و سفيد كاري | 15d | 2007-11-30 | 2007-12-14 | 138, 139 | 2007-10-12 | 2007-10-26 | 15d | 124d | 0d |
| 141 | 5.9.10 | كف‌سازي | 10d | 2007-12-15 | 2007-12-24 | 140 | 2007-10-27 | 2007-11-05 | 10d | 124d | 0d |
| 142 | 5.9.11 | اجراي كارهاي سنگي | 8d | 2007-12-17 | 2007-12-24 | 141FF | 2007-10-29 | 2007-11-05 | 8d | 124d | 0d |
| 143 | 5.9.12 | اجراي آجر نما | 15d | 2007-12-25 | 2008-01-08 | 142 | 2007-11-06 | 2007-11-20 | 15d | 124d | 0d |
| 144 | 5.9.13 | نصب درهاي داخل ساختمان و رنگ آميزي سطوح ديوارها و دربها | 15d | 2007-12-25 | 2008-01-08 | 141 | 2007-11-06 | 2007-11-20 | 15d | 125d | 1d |
| 145 | 5.9.14 | نصب شيشه | 1d | 2008-01-09 | 2008-01-09 | 144FF, 143 | 2007-11-21 | 2007-11-21 | 1d | 124d |  |
| 146 | 5.10 | **منبع هوايي آب** | 73d | 2007-08-27 | 2007-11-07 |  |  |  |  | 187d |  |
| 147 | 5.10.1 | پي‌كني و بتن مگر | 6d | 2007-08-27 | 2007-09-01 | 132SS | 2007-07-09 | 2007-07-14 | 6d | 187d | 0d |
| 148 | 5.10.2 | قالب‌بندي، آرماتوربندي، نصب صفحه ستونها و اجراي فونداسيون | 15d | 2007-09-02 | 2007-09-16 | 147 | 2007-07-15 | 2007-07-29 | 15d | 187d | 0d |
| 149 | 5.10.3 | ساخت و نصب منبع آب هوايي | 32d | 2007-09-17 | 2007-10-18 | 148 | 2007-08-10 | 2007-08-15 | 6d | 187d | 0d |
| 150 | 5.10.4 | رنگ آميزي اپوکسي سطوح فلزي مورد نياز | 5d | 2007-10-19 | 2007-10-23 | 149 | 2007-08-16 | 2007-08-20 | 5d | 187d | 0d |
| 151 | 5.10.5 | اجراي تأسيسات مكانيكي ساختمان | 15d | 2007-10-24 | 2007-11-07 | 150 | 2007-08-31 | 2007-09-14 | 15d | 187d | 0d |
| 152 | 5.10.6 | اجراي تأسيسات برقي ساختمان | 10d | 2007-10-29 | 2007-11-07 | 151FF | 2007-09-05 | 2007-09-14 | 10d | 187d |  |
| 153 | 6 | **عمليات راهسازي** | 306d | 2006-12-22 | 2007-10-23 |  |  |  |  | 0d |  |
| 154 | 6.1 | **محور شرقي** | 127d | 2006-12-22 | 2007-04-27 |  |  |  |  | 0d |  |
| 155 | 6.1.1 | **عمليات خاکبرداري** | 20d | 2006-12-22 | 2007-01-10 |  |  |  |  | 0d |  |
| 156 | 6.1.1.1 | عمليات خاکبرداري مسير | 10d | 2006-12-22 | 2006-12-31 | 7, 18 | 2006-11-22 | 2006-12-01 | 10d | 0d |  |
| 157 | 6.1.1.2 | بارگيري و حمل خاک مسير به محل دپو | 10d | 2007-01-01 | 2007-01-10 | 156 | 2006-12-02 | 2006-12-11 | 10d | 0d |  |

| ID | WBS | Task | Duration | Start | Finish | Predecessors | Baseline start | Baseline finish | Baseline duration | Total slack | Free slack |
| --- | --- | --- | --- | --- | --- | --- | --- | --- | --- | --- | --- |
| 158 | 6.1.2 | **عمليات خاکريزي تا سطح سابگريد** | 20d | 2007-01-11 | 2007-01-30 |  |  |  |  | 0d |  |
| 159 | 6.1.2.1 | تهيه مصالح، بارگيري و حمل تا مسير خاکريزي | 10d | 2007-01-11 | 2007-01-20 | 10, 157 | 2006-12-12 | 2007-01-10 | 30d | 0d |  |
| 160 | 6.1.2.2 | پخش، آبپاشي و تراکم لايه‌هاي خاکريزي | 10d | 2007-01-21 | 2007-01-30 | 159SS+10d | 2006-12-22 | 2007-01-20 | 30d | 0d |  |
| 161 | 6.1.3 | **عمليات اجراي زير اساس** | 35d | 2007-01-31 | 2007-03-06 |  |  |  |  | 78d |  |
| 162 | 6.1.3.1 | تهيه مصالح، بارگيري و حمل تا مسير خاکريزي | 25d | 2007-01-31 | 2007-02-24 | 160 | 2007-01-21 | 2007-02-14 | 25d | 78d | 0d |
| 163 | 6.1.3.2 | پخش، آبپاشي و تراکم لايه‌هاي خاکريزي | 25d | 2007-02-10 | 2007-03-06 | 162SS+10d | 2007-01-31 | 2007-02-24 | 25d | 78d | 0d |
| 164 | 6.1.4 | **عمليات اجراي اساس** | 27d | 2007-03-07 | 2007-04-02 |  |  |  |  | 381d |  |
| 165 | 6.1.4.1 | تهيه مصالح، بارگيري و حمل تا مسير خاکريزي | 20d | 2007-03-07 | 2007-03-26 | 163 | 2007-02-25 | 2007-03-16 | 20d | 381d | 0d |
| 166 | 6.1.4.2 | پخش، آبپاشي و تراکم لايه‌هاي خاکريزي | 20d | 2007-03-14 | 2007-04-02 | 165SS+7d | 2007-03-04 | 2007-03-23 | 20d | 381d | 0d |
| 167 | 6.1.5 | **عمليات اجراي آسفالت** | 25d | 2007-04-03 | 2007-04-27 |  |  |  |  | 381d |  |
| 168 | 6.1.5.1 | تهيه مصالح و اجراي اندودهاي پريمكت و تك كت | 25d | 2007-04-03 | 2007-04-27 | 166 | 2007-03-24 | 2007-04-17 | 25d | 381d | 0d |
| 169 | 6.1.5.2 | تهيه و اجراي بتن آسفالتي بيندر و توپكا | 25d | 2007-04-03 | 2007-04-27 | 168SS | 2007-03-24 | 2007-04-17 | 25d | 381d |  |
| 170 | 6.2 | **محور پشت اسكله** | 146d | 2007-01-31 | 2007-06-25 |  |  |  |  | 0d |  |
| 171 | 6.2.1 | **عمليات خاکبرداري** | 24d | 2007-01-31 | 2007-02-23 |  |  |  |  | 0d |  |
| 172 | 6.2.1.1 | عمليات خاکبرداري مسير | 12d | 2007-01-31 | 2007-02-11 | 160 | 2007-01-29 | 2007-02-09 | 12d | 0d |  |
| 173 | 6.2.1.2 | بارگيري و حمل خاک مسير به محل دپو | 12d | 2007-02-12 | 2007-02-23 | 172 | 2007-02-10 | 2007-02-21 | 12d | 0d |  |
| 174 | 6.2.2 | **عمليات خاکريزي تا سطح سابگريد** | 20d | 2007-02-24 | 2007-03-15 |  |  |  |  | 0d |  |
| 175 | 6.2.2.1 | تهيه مصالح، بارگيري و حمل تا مسير خاکريزي | 10d | 2007-02-24 | 2007-03-05 | 173 | 2007-02-22 | 2007-04-02 | 40d | 0d |  |
| 176 | 6.2.2.2 | پخش، آبپاشي و تراکم لايه‌هاي خاکريزي | 10d | 2007-03-06 | 2007-03-15 | 175SS+10d | 2007-03-04 | 2007-04-12 | 40d | 0d |  |
| 177 | 6.2.3 | **عمليات اجراي زير اساس** | 40d | 2007-03-16 | 2007-04-24 |  |  |  |  | 322d |  |
| 178 | 6.2.3.1 | تهيه مصالح، بارگيري و حمل تا مسير خاکريزي | 30d | 2007-03-16 | 2007-04-14 | 176 | 2007-04-13 | 2007-05-12 | 30d | 322d | 0d |
| 179 | 6.2.3.2 | پخش، آبپاشي و تراکم لايه‌هاي خاکريزي | 30d | 2007-03-26 | 2007-04-24 | 178SS+10d | 2007-04-23 | 2007-05-22 | 30d | 322d | 0d |
| 180 | 6.2.4 | **عمليات اجراي اساس** | 32d | 2007-04-25 | 2007-05-26 |  |  |  |  | 322d |  |
| 181 | 6.2.4.1 | تهيه مصالح، بارگيري و حمل تا مسير خاکريزي | 25d | 2007-04-25 | 2007-05-19 | 179 | 2007-05-23 | 2007-06-16 | 25d | 322d | 0d |
| 182 | 6.2.4.2 | پخش، آبپاشي و تراکم لايه‌هاي خاکريزي | 25d | 2007-05-02 | 2007-05-26 | 181SS+7d | 2007-05-30 | 2007-06-23 | 25d | 322d | 0d |

| ID | WBS | Task | Duration | Start | Finish | Predecessors | Baseline start | Baseline finish | Baseline duration | Total slack | Free slack |
| --- | --- | --- | --- | --- | --- | --- | --- | --- | --- | --- | --- |
| 183 | 6.2.5 | **عمليات اجراي آسفالت** | 30d | 2007-05-27 | 2007-06-25 |  |  |  |  | 322d |  |
| 184 | 6.2.5.1 | تهيه مصالح و اجراي اندودهاي پريمكت و تك كت | 30d | 2007-05-27 | 2007-06-25 | 182 | 2007-06-24 | 2007-07-23 | 30d | 322d | 0d |
| 185 | 6.2.5.2 | تهيه و اجراي بتن آسفالتي بيندر و توپكا | 30d | 2007-05-27 | 2007-06-25 | 184SS | 2007-06-24 | 2007-07-23 | 30d | 322d |  |
| 186 | 6.3 | **بلوار اصلي** | 222d | 2007-03-16 | 2007-10-23 |  |  |  |  | 0d |  |
| 187 | 6.3.1 | **عمليات خاکبرداري** | 60d | 2007-03-16 | 2007-05-14 |  |  |  |  | 0d |  |
| 188 | 6.3.1.1 | عمليات خاکبرداري مسير | 30d | 2007-03-16 | 2007-04-14 | 176 | 2007-04-23 | 2007-06-01 | 40d | 0d |  |
| 189 | 6.3.1.2 | بارگيري و حمل خاک مسير به محل دپو | 30d | 2007-04-15 | 2007-05-14 | 188 | 2007-06-02 | 2007-07-11 | 40d | 0d |  |
| 190 | 6.3.2 | **عمليات خاکريزي تا سطح سابگريد** | 40d | 2007-05-15 | 2007-06-23 |  |  |  |  | 0d |  |
| 191 | 6.3.2.1 | تهيه مصالح، بارگيري و حمل تا مسير خاکريزي | 30d | 2007-05-15 | 2007-06-13 | 189 | 2007-07-12 | 2007-09-09 | 60d | 0d |  |
| 192 | 6.3.2.2 | پخش، آبپاشي و تراکم لايه‌هاي خاکريزي | 30d | 2007-05-25 | 2007-06-23 | 191SS+10d | 2007-07-22 | 2007-09-19 | 60d | 0d |  |
| 193 | 6.3.3 | **عمليات اجراي زير اساس** | 50d | 2007-06-24 | 2007-08-12 |  |  |  |  | 202d |  |
| 194 | 6.3.3.1 | تهيه مصالح، بارگيري و حمل تا مسير خاکريزي | 40d | 2007-06-24 | 2007-08-02 | 192 | 2007-09-20 | 2007-10-29 | 40d | 202d | 0d |
| 195 | 6.3.3.2 | پخش، آبپاشي و تراکم لايه‌هاي خاکريزي | 40d | 2007-07-04 | 2007-08-12 | 194SS+10d | 2007-09-30 | 2007-11-08 | 40d | 202d | 0d |
| 196 | 6.3.4 | **عمليات اجراي اساس** | 37d | 2007-08-13 | 2007-09-18 |  |  |  |  | 202d |  |
| 197 | 6.3.4.1 | تهيه مصالح، بارگيري و حمل تا مسير خاکريزي | 30d | 2007-08-13 | 2007-09-11 | 195 | 2007-11-09 | 2007-12-08 | 30d | 202d | 0d |
| 198 | 6.3.4.2 | پخش، آبپاشي و تراکم لايه‌هاي خاکريزي | 30d | 2007-08-20 | 2007-09-18 | 197SS+7d | 2007-11-16 | 2007-12-15 | 30d | 202d | 0d |
| 199 | 6.3.5 | **عمليات اجراي آسفالت** | 35d | 2007-09-19 | 2007-10-23 |  |  |  |  | 202d |  |
| 200 | 6.3.5.1 | تهيه مصالح و اجراي اندودهاي پريمكت و تك كت | 35d | 2007-09-19 | 2007-10-23 | 198 | 2007-12-16 | 2008-01-19 | 35d | 202d | 0d |
| 201 | 6.3.5.2 | تهيه و اجراي بتن آسفالتي بيندر و توپكا | 35d | 2007-09-19 | 2007-10-23 | 200SS | 2007-12-16 | 2008-01-19 | 35d | 202d |  |
| 202 | 7 | **احداث منهول‌ها** | 135d | 2007-03-16 | 2007-07-28 |  |  |  |  | 289d |  |
| 203 | 7.1 | اجراي منهول‌هاي كل پروژه | 135d | 2007-03-16 | 2007-07-28 | 176 | 2007-04-13 | 2007-08-18 | 128d | 289d |  |
| 204 | 8 | **محوطه‌سازي و اجراي ديوار** | 488d | 2006-12-22 | 2008-04-22 |  |  |  |  | 20d |  |
| 205 | 8.1 | **اجراي جداول و پياده رو ها** | 430d | 2006-12-22 | 2008-02-24 |  |  |  |  | 78d |  |
| 206 | 8.1.1 | ساخت و عمل‌آوري جداول | 120d | 2006-12-22 | 2007-04-20 | 18 | 2006-11-22 | 2007-03-01 | 100d | 78d | 0d |
| 207 | 8.1.2 | حمل جداول | 120d | 2007-01-21 | 2007-05-20 | 206SS+30d | 2006-12-07 | 2007-03-16 | 100d | 358d |  |
| 208 | 8.1.3 | اجراي پياده روها و محوطه‌ها | 265d | 2007-02-20 | 2007-11-11 | 163SS+10d, 206SS+60d | 2007-02-10 | 2007-11-01 | 265d | 78d | 0d |
| 209 | 8.1.4 | اجراي تأسيسات برقي و مكانيكي محوطه | 120d | 2007-10-28 | 2008-02-24 | 208FS-15d | 2007-10-03 | 2008-01-10 | 100d | 78d |  |

| ID | WBS | Task | Duration | Start | Finish | Predecessors | Baseline start | Baseline finish | Baseline duration | Total slack |
| --- | --- | --- | --- | --- | --- | --- | --- | --- | --- | --- |
| 210 | 8.2 | **اجراي ديوار اطراف سايت** | 304d | 2007-06-24 | 2008-04-22 |  |  |  |  | 0d |
| 211 | 8.2.1 | خاكبرداري مسير ديوار، پي کني و اجراي فونداسيون | 90d | 2007-06-24 | 2007-09-21 | 192 | 2007-07-12 | 2007-09-09 | 60d | 0d |
| 212 | 8.2.2 | اجراي ديوارها | 175d | 2007-08-13 | 2008-02-03 | 211FS-40d | 2007-08-01 | 2008-01-22 | 175d | 0d |
| 213 | 8.2.3 | اجراي آجر نما | 150d | 2007-11-25 | 2008-04-22 | 212FS-71d | 2007-11-13 | 2008-04-10 | 150d | 0d |
| 214 | 9 | **برچيدن کارگاه** | 20d | 2008-04-23 | 2008-05-12 |  |  |  |  | 0d |
| 215 | 9.1 | برچيدن کارگاه | 20d | 2008-04-23 | 2008-05-12 | 213 | 2008-04-11 | 2008-04-30 | 20d | 0d |
